# Inicio de la práctica 2

How a schedule from MS Project changed from version to version. A marks actual dates.

## Version 1 (saved 2009-03-05, file 2009-2-2-asignacionrecursos.mpp)

| ID | WBS | Task | Duration | Start | Finish | Predecessors | Total float |
| --- | --- | --- | --- | --- | --- | --- | --- |
| 1 | 1 | **Topografía** | 101.5d | 2008-10-01 | 2009-02-25 |  | 0d |
| 2 |  | Implantación topográfica | 3d | 2008-10-01 | 2008-10-03 |  | 0d |
| 3 |  | Control topográfico antes de colocación de vigas | 0.5d | 2009-02-12 | 2009-02-12 | 34 | 1.5d |
| 4 |  | Control topográfico después de colocación de vigas | 0.5d | 2009-02-25 | 2009-02-25 | 37 | 0d |
| 5 | 2 | **Instalación de la obra** | 15d | 2008-10-06 | 2008-10-24 |  | 0d |
| 6 |  | Colocación planta de hormigonado | 15d | 2008-10-06 | 2008-10-24 | 2 | 0d |
| 7 |  | Instalación de la obra | 5d | 2008-10-06 | 2008-10-10 | 2 | 5d |
| 8 | 3 | **Prefabricación pilotes. Ferralla y encofrado** | 15d | 2008-10-13 | 2008-10-31 |  | 5d |
| 9 |  | Ferralla y encofrado lote 1 | 5d | 2008-10-13 | 2008-10-17 | 7 | 5d |
| 10 |  | Ferralla y encofrado lote 2 | 5d | 2008-10-20 | 2008-10-24 | 9 | 21d |
| 11 |  | Ferralla y encofrado lote 3 | 5d | 2008-10-27 | 2008-10-31 | 10 | 37d |
| 12 | 4 | **Prefebricación pilotes. Hormigonado** | 6d | 2008-10-27 | 2008-11-03 |  | 0d |
| 13 |  | Hormigonado lote 1 | 1d | 2008-10-27 | 2008-10-27 | 6, 9 | 0d |
| 14 |  | Hormigonado lote 2 | 1d | 2008-10-27 | 2008-10-27 | 10 | 21d |
| 15 |  | Hormigonado lote 3 | 1d | 2008-11-03 | 2008-11-03 | 11 | 37d |
| 16 | 5 | **Hincado de pilotes** | 32d | 2008-11-12 | 2008-12-29 |  | 0d |
| 17 |  | Hincado de pilotes de pilar A | 6d | 2008-11-12 | 2008-11-19 | 21, 13FS+15ed | 0d |
| 18 |  | Hincado de pilotes de pilar B | 6d | 2008-12-01 | 2008-12-09 | 22, 14FS+15ed | 7d |
| 19 |  | Hincado de pilotes de pilar C | 6d | 2008-12-19 | 2008-12-29 | 23, 15FS+15ed | 14d |
| 20 | 6 | **Diques provisionales** | 86d | 2008-10-13 | 2009-02-13 |  | 0d |
| 21 |  | Instalación de diques provisionales pilar A | 7d | 2008-10-13 | 2008-10-21 | 7 | 15d |
| 22 |  | Instalación de diques provisionales pilar B | 7d | 2008-11-20 | 2008-11-28 | 17 | 7d |
| 23 |  | Instalación de diques provisionales pilar C | 7d | 2008-12-10 | 2008-12-18 | 18, 26 | 14d |
| 24 |  | Recuperación de planchas | 2d | 2009-02-12 | 2009-02-13 | 34 | 0d |
| 25 | 7 | **Pasarela** | 93d | 2008-10-13 | 2009-02-24 |  | 12.5d |
| 26 |  | Instalación pasarelas | 5d | 2008-10-13 | 2008-10-17 | 7 | 50d |
| 27 |  | Desmontaje pasarelas | 7d | 2009-02-16 | 2009-02-24 | 24 | 12.5d |
| 28 | 8 | **Hormigonado de pilares** | 56d | 2008-11-20 | 2009-02-11 |  | 0d |
| 29 |  | Confección traviesas pilar A | 5d | 2008-11-20 | 2008-11-26 | 17 | 0d |
| 30 |  | Hormigonado pilar A | 15d | 2008-11-27 | 2008-12-18 | 29 | 0d |
| 31 |  | Confección traviesas pilar B | 5d | 2008-12-19 | 2008-12-26 | 18, 30 | 0d |
| 32 |  | Hormigonado pilar B | 15d | 2008-12-29 | 2009-01-20 | 31 | 0d |
| 33 |  | Confección traviesas pilar C | 5d | 2009-01-21 | 2009-01-27 | 19, 32 | 0d |
| 34 |  | Hormigonado pilar C | 11d | 2009-01-28 | 2009-02-11 | 33 | 0d |
| 35 | 9 | **Tablero** | 14.5d | 2009-02-16 | 2009-03-06 |  | 0d |
| 36 |  | Colocación vigas prefabricadas | 2d | 2009-02-16 | 2009-02-17 | 3, 24 | 0d |
| 37 |  | Encofrado tablero | 5d | 2009-02-18 | 2009-02-24 | 36 | 0d |
| 38 |  | Ferralla tablero | 5d | 2009-02-25 | 2009-03-04 | 4, 37 | 0d |
| 39 |  | Hormigonado tablero | 2d | 2009-03-04 | 2009-03-06 | 38 | 0d |
| 40 | 10 | **Pretil** | 113.5d | 2008-10-01 | 2009-03-13 |  | 0d |
| 41 |  | Pedido pretil | 0d | 2008-10-01 | 2008-10-01 |  | 88.5d |
| 42 |  | Colocación pretil | 5d | 2009-03-06 | 2009-03-13 | 39, 41FS+20d | 0d |

## Version 2 (saved 2009-03-12, file InicioPractica3.mpp)

Last finish 2009-03-13 → 2009-03-26 (+13d).

Changed:

| ID | Task | Start | Finish | Duration | Total float |
| --- | --- | --- | --- | --- | --- |
| 1 | **Topografía** |  | 2009-02-25 → 2009-03-09 (+12d) | 101.5d → 109.5d |  |
| 3 | Control topográfico antes de colocación de vigas | 2009-02-12 → 2009-02-24 (+12d) | 2009-02-12 → 2009-02-24 (+12d) |  |  |
| 4 | Control topográfico después de colocación de vigas | 2009-02-25 → 2009-03-09 (+12d) | 2009-02-25 → 2009-03-09 (+12d) |  |  |
| 5 | **Instalación de la obra** |  | 2008-10-24 → 2008-10-31 (+7d) | 15d → 20d |  |
| 6 | Colocación planta de hormigonado | 2008-10-06 → 2008-10-13 (+7d) | 2008-10-24 → 2008-10-31 (+7d) |  |  |
| 12 | **Prefebricación pilotes. Hormigonado** | 2008-10-27 → 2008-11-03 (+7d) | 2008-11-03 → 2008-11-14 (+11d) | 6d → 10d |  |
| 13 | Hormigonado lote 1 | 2008-10-27 → 2008-11-03 (+7d) | 2008-10-27 → 2008-11-03 (+7d) |  |  |
| 14 | Hormigonado lote 2 | 2008-10-27 → 2008-11-13 (+17d) | 2008-10-27 → 2008-11-13 (+17d) |  | 21d → 16d |
| 15 | Hormigonado lote 3 | 2008-11-03 → 2008-11-14 (+11d) | 2008-11-03 → 2008-11-14 (+11d) |  | 37d → 34d |
| 16 | **Hincado de pilotes** | 2008-11-12 → 2008-11-24 (+12d) | 2008-12-29 → 2009-01-12 (+14d) |  |  |
| 17 | Hincado de pilotes de pilar A | 2008-11-12 → 2008-11-24 (+12d) | 2008-11-19 → 2008-12-01 (+12d) |  |  |
| 18 | Hincado de pilotes de pilar B | 2008-12-01 → 2008-12-12 (+11d) | 2008-12-09 → 2008-12-19 (+10d) |  |  |
| 19 | Hincado de pilotes de pilar C | 2008-12-19 → 2009-01-02 (+14d) | 2008-12-29 → 2009-01-12 (+14d) |  |  |
| 20 | **Diques provisionales** | 2008-10-13 → 2008-11-04 (+22d) | 2009-02-13 → 2009-02-25 (+12d) | 86d → 78d |  |
| 21 | Instalación de diques provisionales pilar A | 2008-10-13 → 2008-11-04 (+22d) | 2008-10-21 → 2008-11-12 (+22d) |  | 15d → 4d |
| 22 | Instalación de diques provisionales pilar B | 2008-11-20 → 2008-12-02 (+12d) | 2008-11-28 → 2008-12-11 (+13d) |  |  |
| 23 | Instalación de diques provisionales pilar C | 2008-12-10 → 2008-12-22 (+12d) | 2008-12-18 → 2008-12-31 (+13d) |  |  |
| 24 | Recuperación de planchas | 2009-02-12 → 2009-02-24 (+12d) | 2009-02-13 → 2009-02-25 (+12d) |  |  |
| 25 | **Pasarela** | 2008-10-13 → 2008-11-17 (+35d) | 2009-02-24 → 2009-03-10 (+14d) | 93d → 78d | 12.5d → 10.5d |
| 26 | Instalación pasarelas | 2008-10-13 → 2008-11-17 (+35d) | 2008-10-17 → 2008-11-21 (+35d) |  | 50d → 33d |
| 27 | Desmontaje pasarelas | 2009-02-16 → 2009-03-02 (+14d) | 2009-02-24 → 2009-03-10 (+14d) |  | 12.5d → 10.5d |
| 28 | **Hormigonado de pilares** | 2008-11-20 → 2008-12-02 (+12d) | 2009-02-11 → 2009-02-23 (+12d) |  |  |
| 29 | Confección traviesas pilar A | 2008-11-20 → 2008-12-02 (+12d) | 2008-11-26 → 2008-12-09 (+13d) |  |  |
| 30 | Hormigonado pilar A | 2008-11-27 → 2008-12-10 (+13d) | 2008-12-18 → 2008-12-31 (+13d) |  |  |
| 31 | Confección traviesas pilar B | 2008-12-19 → 2009-01-02 (+14d) | 2008-12-26 → 2009-01-09 (+14d) |  |  |
| 32 | Hormigonado pilar B | 2008-12-29 → 2009-01-12 (+14d) | 2009-01-20 → 2009-01-30 (+10d) |  |  |
| 33 | Confección traviesas pilar C | 2009-01-21 → 2009-02-02 (+12d) | 2009-01-27 → 2009-02-06 (+10d) |  |  |
| 34 | Hormigonado pilar C | 2009-01-28 → 2009-02-09 (+12d) | 2009-02-11 → 2009-02-23 (+12d) |  |  |
| 35 | **Tablero** | 2009-02-16 → 2009-02-26 (+10d) | 2009-03-06 → 2009-03-18 (+12d) |  |  |
| 36 | Colocación vigas prefabricadas | 2009-02-16 → 2009-02-26 (+10d) | 2009-02-17 → 2009-02-27 (+10d) |  |  |
| 37 | Encofrado tablero | 2009-02-18 → 2009-03-02 (+12d) | 2009-02-24 → 2009-03-06 (+10d) |  |  |
| 38 | Ferralla tablero | 2009-02-25 → 2009-03-09 (+12d) | 2009-03-04 → 2009-03-16 (+12d) |  |  |
| 39 | Hormigonado tablero | 2009-03-04 → 2009-03-16 (+12d) | 2009-03-06 → 2009-03-18 (+12d) |  |  |
| 40 | **Pretil** |  | 2009-03-13 → 2009-03-26 (+13d) | 113.5d → 121.5d |  |
| 42 | Colocación pretil | 2009-03-06 → 2009-03-18 (+12d) | 2009-03-13 → 2009-03-26 (+13d) |  |  |

## Version 3 (saved 2009-03-12, file 2009-3-1-unidadesfijas.mpp)

Last finish 2009-03-26 → 2009-03-17 (-9d).

Changed:

| ID | Task | Start | Finish | Duration | Other |
| --- | --- | --- | --- | --- | --- |
| 1 | **Topografía** |  | 2009-03-09 → 2009-03-04 (-5d) | 109.5d → 107d |  |
| 4 | Control topográfico después de colocación de vigas | 2009-03-09 → 2009-03-04 (-5d) | 2009-03-09 → 2009-03-04 (-5d) |  |  |
| 35 | **Tablero** |  | 2009-03-18 → 2009-03-10 (-8d) | 14.5d → 8.5d |  |
| 37 | Encofrado tablero |  | 2009-03-06 → 2009-03-04 (-2d) | 5d → 2.5d | resources Peones [200%]; Albañiles [200%]; Grúa [5%] → Peones [400%]; Albañiles [400%]; Grúa [10%] |
| 38 | Ferralla tablero | 2009-03-09 → 2009-03-05 (-4d) | 2009-03-16 → 2009-03-09 (-7d) | 5d → 2.5d | resources Peones [200%]; Albañiles [200%]; Grúa [5%] → Peones [400%]; Albañiles [400%]; Grúa [10%] |
| 39 | Hormigonado tablero | 2009-03-16 → 2009-03-09 (-7d) | 2009-03-18 → 2009-03-10 (-8d) | 2d → 1d | resources Peones [200%]; Albañiles [200%]; Grúa [50%] → Peones [400%]; Albañiles [400%]; Grúa |
| 40 | **Pretil** |  | 2009-03-26 → 2009-03-17 (-9d) | 121.5d → 115.5d |  |
| 42 | Colocación pretil | 2009-03-18 → 2009-03-10 (-8d) | 2009-03-26 → 2009-03-17 (-9d) |  |  |

## Version 4 (saved 2009-03-12, file 2009-3-3-unidadesfijas-redistrestandar.mpp)

Last finish 2009-03-17 → 2009-03-18 (+1d).

Changed:

| ID | Task | Start | Finish | Duration |
| --- | --- | --- | --- | --- |
| 35 | **Tablero** |  | 2009-03-10 → 2009-03-11 (+1d) | 8.5d → 10d |
| 39 | Hormigonado tablero | 2009-03-09 → 2009-03-11 (+2d) | 2009-03-10 → 2009-03-11 (+1d) |  |
| 40 | **Pretil** |  | 2009-03-17 → 2009-03-18 (+1d) | 115.5d → 117d |
| 42 | Colocación pretil | 2009-03-10 → 2009-03-12 (+2d) | 2009-03-17 → 2009-03-18 (+1d) |  |

## Version 5 (saved 2009-03-13, file 2009-3-4-lineadebase.mpp)

Last finish stays 2009-03-18.

Changed:

| ID | Task | Other |
| --- | --- | --- |
| 1 | **Topografía** | baseline start none → 2008-10-01; baseline finish none → 2009-03-04 |
| 2 | Implantación topográfica | baseline start none → 2008-10-01; baseline finish none → 2008-10-03 |
| 3 | Control topográfico antes de colocación de vigas | baseline start none → 2009-02-24; baseline finish none → 2009-02-24 |
| 4 | Control topográfico después de colocación de vigas | baseline start none → 2009-03-04; baseline finish none → 2009-03-04 |
| 5 | **Instalación de la obra** | baseline start none → 2008-10-06; baseline finish none → 2008-10-31 |
| 6 | Colocación planta de hormigonado | baseline start none → 2008-10-13; baseline finish none → 2008-10-31 |
| 7 | Instalación de la obra | baseline start none → 2008-10-06; baseline finish none → 2008-10-10 |
| 8 | **Prefabricación pilotes. Ferralla y encofrado** | baseline start none → 2008-10-13; baseline finish none → 2008-10-31 |
| 9 | Ferralla y encofrado lote 1 | baseline start none → 2008-10-13; baseline finish none → 2008-10-17 |
| 10 | Ferralla y encofrado lote 2 | baseline start none → 2008-10-20; baseline finish none → 2008-10-24 |
| 11 | Ferralla y encofrado lote 3 | baseline start none → 2008-10-27; baseline finish none → 2008-10-31 |
| 12 | **Prefebricación pilotes. Hormigonado** | baseline start none → 2008-11-03; baseline finish none → 2008-11-14 |
| 13 | Hormigonado lote 1 | baseline start none → 2008-11-03; baseline finish none → 2008-11-03 |
| 14 | Hormigonado lote 2 | baseline start none → 2008-11-13; baseline finish none → 2008-11-13 |
| 15 | Hormigonado lote 3 | baseline start none → 2008-11-14; baseline finish none → 2008-11-14 |
| 16 | **Hincado de pilotes** | baseline start none → 2008-11-24; baseline finish none → 2009-01-12 |
| 17 | Hincado de pilotes de pilar A | baseline start none → 2008-11-24; baseline finish none → 2008-12-01 |
| 18 | Hincado de pilotes de pilar B | baseline start none → 2008-12-12; baseline finish none → 2008-12-19 |
| 19 | Hincado de pilotes de pilar C | baseline start none → 2009-01-02; baseline finish none → 2009-01-12 |
| 20 | **Diques provisionales** | baseline start none → 2008-11-04; baseline finish none → 2009-02-25 |
| 21 | Instalación de diques provisionales pilar A | baseline start none → 2008-11-04; baseline finish none → 2008-11-12 |
| 22 | Instalación de diques provisionales pilar B | baseline start none → 2008-12-02; baseline finish none → 2008-12-11 |
| 23 | Instalación de diques provisionales pilar C | baseline start none → 2008-12-22; baseline finish none → 2008-12-31 |
| 24 | Recuperación de planchas | baseline start none → 2009-02-24; baseline finish none → 2009-02-25 |
| 25 | **Pasarela** | baseline start none → 2008-11-17; baseline finish none → 2009-03-10 |
| 26 | Instalación pasarelas | baseline start none → 2008-11-17; baseline finish none → 2008-11-21 |
| 27 | Desmontaje pasarelas | baseline start none → 2009-03-02; baseline finish none → 2009-03-10 |
| 28 | **Hormigonado de pilares** | baseline start none → 2008-12-02; baseline finish none → 2009-02-23 |
| 29 | Confección traviesas pilar A | baseline start none → 2008-12-02; baseline finish none → 2008-12-09 |
| 30 | Hormigonado pilar A | baseline start none → 2008-12-10; baseline finish none → 2008-12-31 |
| 31 | Confección traviesas pilar B | baseline start none → 2009-01-02; baseline finish none → 2009-01-09 |
| 32 | Hormigonado pilar B | baseline start none → 2009-01-12; baseline finish none → 2009-01-30 |
| 33 | Confección traviesas pilar C | baseline start none → 2009-02-02; baseline finish none → 2009-02-06 |
| 34 | Hormigonado pilar C | baseline start none → 2009-02-09; baseline finish none → 2009-02-23 |
| 35 | **Tablero** | baseline start none → 2009-02-26; baseline finish none → 2009-03-11 |
| 36 | Colocación vigas prefabricadas | baseline start none → 2009-02-26; baseline finish none → 2009-02-27 |
| 37 | Encofrado tablero | baseline start none → 2009-03-02; baseline finish none → 2009-03-04 |
| 38 | Ferralla tablero | baseline start none → 2009-03-05; baseline finish none → 2009-03-09 |
| 39 | Hormigonado tablero | baseline start none → 2009-03-11; baseline finish none → 2009-03-11 |
| 40 | **Pretil** | baseline start none → 2008-10-01; baseline finish none → 2009-03-18 |
| 41 | Pedido pretil | baseline start none → 2008-10-01; baseline finish none → 2008-10-01 |
| 42 | Colocación pretil | baseline start none → 2009-03-12; baseline finish none → 2009-03-18 |

## Version 6 (data date 2008-12-01, saved 2009-03-13, file 2009-3-6-lineasprogreso.mpp)

Last finish 2009-03-18 → 2009-03-16 (-2d). Complete tasks 0 → 13.

Changed:

| ID | Task | Start | Finish | Duration | Complete | Total float |
| --- | --- | --- | --- | --- | --- | --- |
| 1 | **Topografía** | 2008-10-01 A | 2009-03-04 → 2009-03-02 (-2d) | 107d → 105d | 0% → 75% |  |
| 2 | Implantación topográfica | 2008-10-01 A | 2008-10-03 A |  | 0% → 100% | 0d → none |
| 3 | Control topográfico antes de colocación de vigas | 2009-02-24 → 2009-02-20 (-4d) | 2009-02-24 → 2009-02-20 (-4d) |  |  |  |
| 4 | Control topográfico después de colocación de vigas | 2009-03-04 → 2009-03-02 (-2d) | 2009-03-04 → 2009-03-02 (-2d) |  |  |  |
| 5 | **Instalación de la obra** | 2008-10-06 A | 2008-10-31 A |  | 0% → 100% | 0d → none |
| 6 | Colocación planta de hormigonado | 2008-10-13 A | 2008-10-31 A |  | 0% → 100% | 0d → none |
| 7 | Instalación de la obra | 2008-10-06 A | 2008-10-10 A |  | 0% → 100% | 5d → none |
| 8 | **Prefabricación pilotes. Ferralla y encofrado** | 2008-10-13 A | 2008-10-31 → 2008-11-05 A (+5d) | 15d → 18d | 0% → 100% | 10d → none |
| 9 | Ferralla y encofrado lote 1 | 2008-10-13 A | 2008-10-17 → 2008-10-16 A (-1d) | 5d → 4d | 0% → 100% | 10d → none |
| 10 | Ferralla y encofrado lote 2 | 2008-10-20 A | 2008-10-24 → 2008-10-27 A (+3d) | 5d → 6d | 0% → 100% | 16d → none |
| 11 | Ferralla y encofrado lote 3 | 2008-10-27 → 2008-10-29 A (+2d) | 2008-10-31 → 2008-11-05 A (+5d) | 5d → 6d | 0% → 100% | 38d → none |
| 12 | **Prefebricación pilotes. Hormigonado** | 2008-11-03 A | 2008-11-14 → 2008-11-18 A (+4d) | 10d → 12d | 0% → 100% | 0d → none |
| 13 | Hormigonado lote 1 | 2008-11-03 A | 2008-11-03 A |  | 0% → 100% | 0d → none |
| 14 | Hormigonado lote 2 | 2008-11-13 → 2008-11-17 A (+4d) | 2008-11-13 → 2008-11-17 A (+4d) |  | 0% → 100% | 16d → none |
| 15 | Hormigonado lote 3 | 2008-11-14 → 2008-11-18 A (+4d) | 2008-11-14 → 2008-11-18 A (+4d) |  | 0% → 100% | 34d → none |
| 16 | **Hincado de pilotes** | 2008-11-24 → 2008-11-19 A (-5d) | 2009-01-12 → 2009-01-07 (-5d) |  | 0% → 33% | 0d → 15d |
| 17 | Hincado de pilotes de pilar A | 2008-11-24 → 2008-11-19 A (-5d) | 2008-12-01 → 2008-11-26 A (-5d) |  | 0% → 100% | 0d → none |
| 18 | Hincado de pilotes de pilar B | 2008-12-12 → 2008-12-09 (-3d) | 2008-12-19 → 2008-12-16 (-3d) |  |  | 7d → 8d |
| 19 | Hincado de pilotes de pilar C | 2009-01-02 → 2008-12-29 (-4d) | 2009-01-12 → 2009-01-07 (-5d) |  |  | 14d → 15d |
| 20 | **Diques provisionales** | 2008-11-04 → 2008-11-03 A (-1d) | 2009-02-25 → 2009-02-23 (-2d) | 78d → 77d | 0% → 36% |  |
| 21 | Instalación de diques provisionales pilar A | 2008-11-04 → 2008-11-03 A (-1d) | 2008-11-12 → 2008-11-10 A (-2d) | 7d → 6d | 0% → 100% | 4d → none |
| 22 | Instalación de diques provisionales pilar B | 2008-12-02 → 2008-11-27 A (-5d) | 2008-12-11 → 2008-12-05 (-6d) |  | 0% → 29% | 7d → 8d |
| 23 | Instalación de diques provisionales pilar C | 2008-12-22 → 2008-12-17 (-5d) | 2008-12-31 → 2008-12-26 (-5d) |  |  | 14d → 15d |
| 24 | Recuperación de planchas | 2009-02-24 → 2009-02-20 (-4d) | 2009-02-25 → 2009-02-23 (-2d) |  |  |  |
| 25 | **Pasarela** | 2008-11-17 → 2008-11-18 A (+1d) |  | 78d → 77d | 0% → 42% | 6d → 4d |
| 26 | Instalación pasarelas | 2008-11-17 → 2008-11-18 A (+1d) | 2008-11-21 → 2008-11-24 A (+3d) |  | 0% → 100% | 33d → none |
| 28 | **Hormigonado de pilares** | 2008-12-02 → 2008-11-27 A (-5d) | 2009-02-23 → 2009-02-19 (-4d) | 56d → 57d | 0% → 4% |  |
| 29 | Confección traviesas pilar A | 2008-12-02 → 2008-11-27 A (-5d) | 2008-12-09 → 2008-12-04 (-5d) | 5d → 6d | 0% → 33% |  |
| 30 | Hormigonado pilar A | 2008-12-10 → 2008-12-05 (-5d) | 2008-12-31 → 2008-12-29 (-2d) |  |  |  |
| 31 | Confección traviesas pilar B | 2009-01-02 → 2008-12-30 (-3d) | 2009-01-09 → 2009-01-07 (-2d) |  |  |  |
| 32 | Hormigonado pilar B | 2009-01-12 → 2009-01-08 (-4d) | 2009-01-30 → 2009-01-28 (-2d) |  |  |  |
| 33 | Confección traviesas pilar C | 2009-02-02 → 2009-01-29 (-4d) | 2009-02-06 → 2009-02-04 (-2d) |  |  |  |
| 34 | Hormigonado pilar C | 2009-02-09 → 2009-02-05 (-4d) | 2009-02-23 → 2009-02-19 (-4d) |  |  |  |
| 35 | **Tablero** | 2009-02-26 → 2009-02-24 (-2d) | 2009-03-11 → 2009-03-09 (-2d) |  |  |  |
| 36 | Colocación vigas prefabricadas | 2009-02-26 → 2009-02-24 (-2d) | 2009-02-27 → 2009-02-25 (-2d) |  |  |  |
| 37 | Encofrado tablero | 2009-03-02 → 2009-02-26 (-4d) | 2009-03-04 → 2009-03-02 (-2d) |  |  |  |
| 38 | Ferralla tablero | 2009-03-05 → 2009-03-03 (-2d) | 2009-03-09 → 2009-03-05 (-4d) |  |  |  |
| 39 | Hormigonado tablero | 2009-03-11 → 2009-03-09 (-2d) | 2009-03-11 → 2009-03-09 (-2d) |  |  |  |
| 40 | **Pretil** | 2008-10-01 A | 2009-03-18 → 2009-03-16 (-2d) | 117d → 115d |  |  |
| 41 | Pedido pretil | 2008-10-01 A | 2008-10-01 A |  | 0% → 100% | 92d → none |
| 42 | Colocación pretil | 2009-03-12 → 2009-03-10 (-2d) | 2009-03-18 → 2009-03-16 (-2d) |  |  |  |
